# Plan_เดือนมีนาคม 2547_V02

Schedule from MS Project, 2004-03-01 to 2004-03-30.
softsquare

## Calendars

- Standard: Mon-Fri 08:00-12:00, 13:00-17:00; Sat-Sun off.

## Schedule

| ID | WBS | Task | Duration | Start | Finish | Predecessors | Baseline start | Baseline finish | Baseline duration | Total slack | Free slack | Constraint | Text1 |
| --- | --- | --- | --- | --- | --- | --- | --- | --- | --- | --- | --- | --- | --- |
| 1 | 1 | ทางบริษัทส่งรายงานการออกแบบระดับฟังก์ชัน 10 ระบบ(ฉบับร่าง) | 1d? | 2004-03-01 | 2004-03-01 |  | 2004-03-01 | 2004-03-01 | 1d? | 16d | 0d | start no earlier than 2004-03-01 | SS |
| 2 | 2 | ทางบริษัทส่งรายงานการออกแบบระดับฟังก์ชัน 3 ระบบ(ฉบับร่าง) | 1d? | 2004-03-04 | 2004-03-04 |  | 2004-03-04 | 2004-03-04 | 1d? | 6d | 0d | finish no earlier than 2004-03-04 | SS |
| 3 | 3 | ทีมงานม. ขอนแก่น ตรวจสอบและพิจารณารายงานการออกแบบระดับฟังก์ชัน 10 ระบบ (ฉบับร่าง) และแจ้งกลับบริษัท | 5d? | 2004-03-02 | 2004-03-08 | 1 | 2004-03-02 | 2004-03-08 | 5d? | 15d | 3d | finish no earlier than 2004-03-08 | KKU |
| 4 | 4 | ทีมงานม. ขอนแก่น ตรวจสอบและพิจารณารายงานการออกแบบระดับฟังก์ชัน 3 ระบบ (ฉบับร่าง) และแจ้งกลับบริษัท | 5d? | 2004-03-05 | 2004-03-11 | 2 | 2004-03-05 | 2004-03-11 | 5d? | 12d | 4d | finish no earlier than 2004-03-11 | KKU |
| 5 | 5 | ทางบริษัทส่งรายงานการออกแบบระดับฟังก์ชัน 10 ระบบ (ฉบับจริง) | 1d? | 2004-03-12 | 2004-03-12 | 3 | 2004-03-12 | 2004-03-12 | 1d? | 12d |  | start no earlier than 2004-03-12 | SS |
| 6 | 6 | ทางบริษัทส่งรายงานการออกแบบระดับฟังก์ชัน 3 ระบบ (ฉบับจริง) | 1d? | 2004-03-18 | 2004-03-18 | 4 | 2004-03-18 | 2004-03-18 | 1d? | 8d |  | start no earlier than 2004-03-18 | SS |
| 7 | 7 | **Technical Design** | 10d? | 2004-03-15 | 2004-03-26 |  |  |  |  | 2d |  |  |  |
| 8 | 7.1 | ทางบริษัทส่งรายงานการออกแบบ Technical Design (ฉบับร่าง) | 1d? | 2004-03-15 | 2004-03-15 |  | 2004-03-15 | 2004-03-15 | 1d? | 7d | 0d | start no earlier than 2004-03-15 | SS |
| 9 | 7.2 | นัดประชุมกับทีมขอนแก่น เรื่องสรุปการออกแบบ Technical Design ของแต่ละระบบ | 4d? | 2004-03-16 | 2004-03-19 | 8 | 2004-03-16 | 2004-03-19 | 4d? | 7d |  | finish no earlier than 2004-03-19 | SS,KKU |
| 10 | 7.3 | ทีมงานม. ขอนแก่น ตรวจสอบและพิจารณารายงานการออกแบบ Technical Design(ฉบับร่าง) | 6d? | 2004-03-15 | 2004-03-22 |  | 2004-03-15 | 2004-03-22 | 6d? | 5d | 3d | finish no earlier than 2004-03-22 | KKU |
| 11 | 7.4 | ทางบริษัทส่งรายงานการออก Technical Design (ฉบับจริง) | 1d? | 2004-03-26 | 2004-03-26 | 10 | 2004-03-26 | 2004-03-26 | 1d? | 2d |  | start no earlier than 2004-03-26 | SS |
| 12 | 8 | **เสนอทางการดำเนินงานต่อไป** | 20d? | 2004-03-01 | 2004-03-26 |  |  |  |  | 2d |  |  |  |
| 13 | 8.1 | บริษัทฯ ส่งแบบสอบถามสำหรับการจัดทำข้อเสนอแนวทางการดำเนินงานด้าน Hardware, Software ระบบปฏิบัติการและ Software ฐานข้อมูล | 1d? | 2004-03-01 | 2004-03-01 |  |  |  |  | 19d | 2d | start no earlier than 2004-03-01 |  |
| 14 | 8.2 | ทีมงานม. ขอนแก่น ส่งแบบสอบถามกลับมาให้บริษัทฯ | 1d? | 2004-03-04 | 2004-03-04 | 13 |  |  |  | 17d | 6d | start no earlier than 2004-03-04 |  |
| 15 | 8.3 | ทางบริษัทส่งรายงานการเสนอแนวทางการดำเนินงานต่อไป (ฉบับร่าง) | 1d? | 2004-03-15 | 2004-03-15 | 14 | 2004-03-26 | 2004-03-26 | 1d? | 11d |  | start no earlier than 2004-03-15 | SS |
| 16 | 8.4 | ทีมงานม. ขอนแก่น ตรวจสอบและพิจารณารายงานการเสนอแนวทางการดำเนินงานต่อไป(ฉบับร่าง) | 6d? | 2004-03-15 | 2004-03-22 |  |  |  |  | 5d | 3d | finish no earlier than 2004-03-22 | KKU |
| 17 | 8.5 | ทางบริษัทส่งรายงานการเสนอแนวทางการดำเนินงานต่อไป (ฉบับจริง) | 1d? | 2004-03-26 | 2004-03-26 | 16 |  |  |  | 2d |  | start no earlier than 2004-03-26 | SS |
| 18 | 9 | **จัดประชุมประชาพิจารณ์** | 2d? | 2004-03-29 | 2004-03-30 |  |  |  |  | 0d |  |  | SS,KKU |
| 19 | 9.1 | นำเสนอให้แก่ผู้บริหารมหาวิทยาลัยขอนแก่น (คณบดี) | 1d? | 2004-03-29 | 2004-03-29 |  |  |  |  | 0d |  | start no earlier than 2004-03-29 | SS,KKU |
| 20 | 9.2 | นำเสนอผู้รับผิดชอบของทุกคณะ/หน่วยงาน | 1d? | 2004-03-29 | 2004-03-29 |  |  |  |  | 0d |  | start no earlier than 2004-03-29 | SS,KKU |
| 21 | 9.3 | สรุปประเด็นปัญหาที่เกิดขึ้นของแต่ละระบบและภาพรวมของโครงการ | 1d? | 2004-03-30 | 2004-03-30 | 19 |  |  |  | 0d |  |  | SS,KKU |
| 22 | 9.4 | ตกลงหาข้อสรุป พร้อมหาแนวทางแก้ไขปัญหาที่เกิดขึ้น | 1d? | 2004-03-30 | 2004-03-30 | 20 |  |  |  | 0d |  |  | SS,KKU |
